# GERAN2 work plan

Schedule from MS Project, 2001-05-11 to 2004-11-12, A marks actual dates.
3GPP work plan
Vodafone Group
Tel: +44 1635 676093 / E-mail: jose-luis.carrizo@vodafone.co.uk

## Calendars

- Standard: Mon-Fri 08:00-12:00, 13:00-17:00; Sat-Sun off.

## Resources

| Resource |
| --- |
| TSG GERAN |
| WG GERAN1 |
| WG GERAN2 |
| WG GERAN4 |
| GERAN1 |
| G2 |
| GERAN4/5 |
| GERAN 4/5 |
| GERAN3 |
| CN1 |
| SA1 |
| SA2 |
| TSG RAN |
| TSG CN |
| SA3 |
| GP |
| G4 |
| G5 |
| S1 |
| S2 |
| R2 |
| N1 |
| S3 |
| G1 |
| G2 |
| G3 |

## Schedule

| ID | WBS | Task | Duration | Start | Finish | Predecessors | Complete | Remaining | Baseline start | Baseline finish | Baseline duration | Total slack | Free slack | Constraint | Resources | Work | Actual work | Text6 | Text1 | Text2 | Text3 | Text8 | Text9 | Text7 |
| --- | --- | --- | --- | --- | --- | --- | --- | --- | --- | --- | --- | --- | --- | --- | --- | --- | --- | --- | --- | --- | --- | --- | --- | --- |
| 1 | 1 | VERSION 12.1 (16 January 2004) | 1d | 2002-01-01 | 2002-01-01 |  |  |  | 2000-01-03 | 2000-01-03 | 1d | 748d |  |  |  |  |  | Rel |  |  |  |  |  |  |
| 3 | 4 | **Flexible Layer One for GERAN** | 571d | 2002-04-19 A | 2004-06-25 |  | 73% | 155.15d | 2000-01-03 | 2002-06-28 | 650d | 100d |  |  | GP | 14704h | 6799.2h | Rel6 | FLOGER | Benoist Sébire, Nokia | benoist.sebire@nokia.com |  |  |  |
| 4 | 4.1 | Realisation of a Flexible Layer One | 471d | 2002-04-19 A | 2004-02-06 |  | 90% | 47.1d | 2000-01-03 | 2002-06-28 | 650d | 100d | 0d | finish no earlier than 2004-02-06 | GP | 3768h | 3391.2h |  | FLOGER-Real | Benoist Sébire, Nokia | benoist.sebire@nokia.com |  |  |  |
| 5 | 4.2 | Signalling and protocol support for a Flexible Layer One | 350d | 2002-10-07 A | 2004-02-06 |  | 80% | 70d | 2002-04-19 | 2002-06-28 | 51d | 100d | 0d | finish no earlier than 2004-02-06 | G2 | 2800h | 2240h |  | FLOGER-SigPro | Benoist Sébire, Nokia | benoist.sebire@nokia.com |  |  |  |
| 6 | 4.3 | Security for a Flexible Layer One | 146d | 2003-02-07 A | 2003-08-29 A |  | 100% |  | 2002-04-19 | 2002-06-28 | 51d |  |  | finish no earlier than 2003-08-29 | G2 | 1168h | 1168h |  | FLOGER-SecFLO | Benoist Sébire, Nokia | benoist.sebire@nokia.com |  |  |  |
| 7 | 4.4 | GERAN MS Conformance test for the Flexible Layer One | 100d | 2004-02-09 | 2004-06-25 | 4, 5, 6 |  |  | 2002-04-19 | 2002-06-28 | 51d | 100d |  | finish no earlier than 2004-06-25 | G4; G5 | 1600h |  |  | FLOGER-Msconf | Benoist Sébire, Nokia | benoist.sebire@nokia.com |  |  |  |
| 8 | 4.5 | GERAN BTS Conformance test for the Flexible Layer One | 100d | 2004-02-09 | 2004-06-25 | 4, 5, 6 |  |  | 2002-04-19 | 2002-06-28 | 51d | 100d |  | finish no earlier than 2004-06-25 | G3 | 800h |  |  | FLOGER-BTSconf | Benoist Sébire, Nokia | benoist.sebire@nokia.com |  |  |  |
| 9 | 6 | **Multimedia Broadcast and Multicast Service** | 816d | 2001-05-11 A | 2004-06-25 |  | 52% | 392.09d | 2001-05-11 | 2003-09-30 | 623d | 100d |  |  |  | 23368h | 11570.6h | Rel6 | MBMS |  |  | Michael C. |  |  |
| 10 | 6.1 | Stage 1 | 232d | 2001-05-11 A | 2002-04-01 A |  | 100% |  | 2001-05-11 | 2002-04-01 | 232d |  |  | finish no earlier than 2002-04-01 | S1 | 1856h | 1856h |  |  |  |  | Micheal C | 11003 |  |
| 11 | 6.2 | **Stage 2** | 593d | 2001-09-24 A | 2003-12-31 |  | 91% | 53.25d | 2001-08-31 | 2002-09-20 | 276d | 227d |  |  | S2 | 9528h | 6249.85h |  |  |  |  |  |  | TSG |
| 12 | 6.2.1 | TR on Architectural Study | 240d | 2001-09-24 A | 2002-08-23 A |  | 100% |  |  |  |  |  |  | finish no earlier than 2002-08-23 | S2 | 1920h | 1920h |  |  |  |  |  |  |  |
| 13 | 6.2.2 | Stage 2 Specification Work | 358d | 2002-08-19 A | 2003-12-31 |  | 85% | 53.7d |  |  |  | 227d |  | finish no earlier than 2003-12-31 | S2 | 2864h | 2434.4h |  |  |  |  |  |  |  |
| 14 | 6.3 | Introduction of MBMS in RAN | 449d | 2002-01-01 A | 2003-09-19 |  | 40% | 269.4d | 2002-01-01 | 2003-09-30 | 456d | 300d |  | finish no earlier than 2003-09-19 | R2 | 3592h | 1436.8h |  |  | Dimitris Koulakiotis, Nokia |  |  | 2481 | TSG |
| 15 | 6.4 | Support of the MBMS in CN protocols | 454d | 2002-06-18 A | 2004-03-12 |  | 25% | 340.5d |  |  |  | 175d |  | finish no earlier than 2004-03-12 | N1 | 3632h | 908h |  |  |  |  |  |  | TSG |
| 16 | 6.5 | Security Aspects of Multimedia Broadcast/Multicast Service (MBMS) | 175d | 2002-07-01 A | 2003-02-28 |  | 20% | 140d |  |  |  | 445d |  | finish no earlier than 2003-02-28 | S3 | 1400h | 280h |  | MBMS | Escott, Adrian, Hutchison 3G UK | adrian.escott@hutchison3g.com |  |  | TSG |
| 17 | 6.6 | Support of MBMS in GERAN | 420d | 2002-11-18 A | 2004-06-25 |  | 25% | 315d |  |  |  | 100d |  | finish no earlier than 2004-06-25 | GP | 3360h | 840h | Rel6 | MBMS-GERAN | José Luis Carrizo Martínez, Vodafone | jose-luis.carrizo@gb.vodafone.co.uk |  |  | TSG |
| 18 | 12 | Uplink TDOA Location Determination for GSM/GPRS - CS domain | 371d? | 2002-11-22 A | 2004-04-23 |  | 90% | 37.1d? |  |  |  | 145d |  | finish no earlier than 2004-04-23 | GP | 2968h | 2671.2h |  | UTDOA-CS | Bob Gross, TruePosition, Inc. | rlgross@trueposition.com |  |  |  |
| 19 | 8 | Uplink TDOA Location Determination for GSM/GPRS - PS domain | 516d? | 2002-11-22 A | 2004-11-12 |  | 5% | 490.2d? |  |  |  | 0d |  |  | GP | 4128h | 206.4h |  | UTDOA-PS | Bob Gross, TruePosition, Inc. | rlgross@trueposition.com |  |  |  |
| 20 | 10 | **Support of Conversational Services in A/Gb Mode via the PS Domain** | 406d? | 2003-02-07 A | 2004-08-27 |  | 24% | 309.82d? |  |  |  | 55d |  |  |  | 7328h | 1736h |  | SCSAGB | David Bladsjö, Ericsson | david.bladsjo@era.ericsson.se |  |  |  |
| 21 | 10.1 | Technical Report | 206d? | 2003-02-07 A | 2003-11-21 A |  | 100% |  |  |  |  |  |  | finish no earlier than 2003-11-21 | GP | 1648h | 1648h |  | SCSAGB-TR | David Bladsjö, Ericsson | david.bladsjo@era.ericsson.se |  |  |  |
| 22 | 10.2 | Stage 2 | 110d? | 2003-11-24 A | 2004-04-23 | 21 | 10% | 99d? |  |  |  | 145d |  | finish no earlier than 2004-04-23 | GP | 880h | 88h |  | SCSAGB-Stage2 | David Bladsjö, Ericsson | david.bladsjo@era.ericsson.se |  |  |  |
| 23 | 10.7 | Radio Channel Support | 150d? | 2004-02-02 | 2004-08-27 |  |  |  |  |  |  | 55d |  | finish no earlier than 2004-08-27 | GP | 1200h |  |  | SCSAGB-RCS | David Bladsjö, Ericsson | david.bladsjo@era.ericsson.se |  |  |  |
| 24 | 10.4 | Definition of Radio Resource Management Functionality | 150d? | 2004-02-02 | 2004-08-27 |  |  |  |  |  |  | 55d |  | finish no earlier than 2004-08-27 | GP | 1200h |  |  | SCSAGB-RRM | David Bladsjö, Ericsson | david.bladsjo@era.ericsson.se |  |  |  |
| 25 | 10.8 | PS Handover | 150d? | 2004-02-02 | 2004-08-27 |  |  |  |  |  |  | 55d |  | finish no earlier than 2004-08-27 | GP | 1200h |  |  | SCSAGB-PSH | David Bladsjö, Ericsson | david.bladsjo@era.ericsson.se |  |  |  |
| 26 | 10.5 | Modifications to FLO | 150d? | 2004-02-02 | 2004-08-27 |  |  |  |  |  |  | 55d |  | finish no earlier than 2004-08-27 | GP | 1200h |  |  | SCSAGB-FLO | David Bladsjö, Ericsson | david.bladsjo@era.ericsson.se |  |  |  |

Notes:
- 3: Nokia, Ericsson, Siemens, Telia / Text4: Nokia, Ericsson, Siemens, Telia
- 4: Text4: Nokia, Ericsson, Siemens, Telia
- 5: Text4: Nokia, Ericsson, Siemens, Telia
- 6: Text4: Nokia, Ericsson, Siemens, Telia
- 7: Text4: Nokia, Ericsson, Siemens, Telia
- 8: Text4: Nokia, Ericsson, Siemens, Telia
- 9: Title renamed at SA#13
- 10: This may or may not be a separate stage 1. In the meantime, CRs are proposed for 22.101
- 16: WID approved SA#17
- 17: Text4: Ericsson, Nokia, Siemens, Vodafone
- 18: Text4: Cingular Wireless, AWS, SBC Technology Resources, Motorola, TruePosition
- 19: Text4: Cingular Wireless, AWS, SBC Technology Resources, Motorola, TruePosition
- 20: Text4: Alcatel, Cingular Wireless, Ericsson, Nortel Networks, Siemens, T-Mobile, Telecom Italia Mobile, Vodafone Group Plc
- 21: Text4: Alcatel, Cingular Wireless, Ericsson, Nortel Networks, Siemens, T-Mobile, Telecom Italia Mobile, Vodafone Group Plc
- 22: Text4: Alcatel, Cingular Wireless, Ericsson, Nortel Networks, Siemens, T-Mobile, Telecom Italia Mobile, Vodafone Group Plc
- 23: Text4: Alcatel, Cingular Wireless, Ericsson, Nortel Networks, Siemens, T-Mobile, Telecom Italia Mobile, Vodafone Group Plc
- 24: Text4: Alcatel, Cingular Wireless, Ericsson, Nortel Networks, Siemens, T-Mobile, Telecom Italia Mobile, Vodafone Group Plc
- 25: Text4: Alcatel, Cingular Wireless, Ericsson, Nortel Networks, Siemens, T-Mobile, Telecom Italia Mobile, Vodafone Group Plc
- 26: Text4: Alcatel, Cingular Wireless, Ericsson, Nortel Networks, Siemens, T-Mobile, Telecom Italia Mobile, Vodafone Group Plc

| ID | WBS | Task | Duration | Start | Finish | Predecessors | Complete | Remaining | Total slack | Free slack | Constraint | Resources | Work | Actual work | Text1 | Text2 | Text3 | Text4 |
| --- | --- | --- | --- | --- | --- | --- | --- | --- | --- | --- | --- | --- | --- | --- | --- | --- | --- | --- |
| 27 | 11 | **Reduction of PS service interruption in Dual Transfer Mode** | 259d? | 2003-11-17 A | 2004-11-12 |  | 24% | 196.58d? | 1d |  |  | GP | 5856h | 1411.38h | PSintDTM | Toby Proctor, Siemens | toby.proctor@roke.co.uk | Siemens, Vodafone, Ericsson, Nokia, T-Mobile |
| 28 | 11.10 | Use case and requirement definition | 114d? | 2003-11-17 A | 2004-04-23 |  | 50% | 57d? | 1d | 0d | finish no earlier than 2004-04-23 | G2 | 912h | 456h | PSintDTM-Req | Toby Proctor, Siemens | toby.proctor@roke.co.uk | Siemens, Vodafone, Ericsson, Nokia, T-Mobile |
| 29 | 11.11 | Performance study of current procedures | 114d? | 2003-11-17 A | 2004-04-23 |  | 50% | 57d? | 1d | 0d | finish no earlier than 2004-04-23 | G2 | 912h | 456h | PSintDTM-Perf | Toby Proctor, Siemens | toby.proctor@roke.co.uk | Siemens, Vodafone, Ericsson, Nokia, T-Mobile |
| 30 | 11.12 | Reduction of service interruption times and packet loss during DTM and mobility procedures | 45d? | 2004-04-23 | 2004-06-25 | 28, 29 |  |  | 1d | 0d | finish no earlier than 2004-06-25 | G2 | 360h |  | PSintDTM-Reduct | Toby Proctor, Siemens | toby.proctor@roke.co.uk | Siemens, Vodafone, Ericsson, Nokia, T-Mobile |
| 31 | 11.13 | MS conformance testing | 100d? | 2004-06-25 | 2004-11-12 | 30 |  |  | 1d |  | finish no earlier than 2004-11-12 | G3 | 800h |  | PSintDTM-Msconf |  |  |  |
| 32 | 11.14 | BTS conformance testing | 100d? | 2004-06-25 | 2004-11-12 | 30 |  |  | 1d |  | finish no earlier than 2004-11-12 | G1 | 800h |  | PSintDTM-BTSconf |  |  |  |
